# MRS 2006 Work Plan

Schedule from MS Project, 2006-01-02 to 2006-04-07.
MBARI

## Calendars

- Standard: Mon-Fri 08:00-12:00, 13:00-17:00; Sat-Sun off.

## Resources

| Resource |
| --- |
| Lance |
| Brett |
| Thomas |
| Machine shop |
| Jon |
| Lance McBride |
| Thomas Hoover |
| Test Tank |
| Rob Mcewen |
| Zephyr |
| Brett Hobson |
| Jon Erickson |
| AUV Fabricator #1 |
| Mike Godin |
| Yanwu Zhang |
| Rich |
| EE |
| SE |
| ME |
| MS |
| RE |
| ET |
| MT |
| 2 |
| SupE |

## Schedule

| ID | WBS | Task | Type | Duration | Start | Finish | Predecessors | Total slack | Resources | Work |
| --- | --- | --- | --- | --- | --- | --- | --- | --- | --- | --- |
| 1 | 1 | **Midwater Respirometer** |  | 69.5d? | 2006-01-02 | 2006-04-07 |  | 0d |  | 704h |
| 2 | 1.1 | **Design Rev.1 MRS** |  | 20d? | 2006-01-02 | 2006-01-27 |  | 0d |  | 176h |
| 3 | 1.1.1 | Electrical layout |  | 1d? | 2006-01-02 | 2006-01-02 |  | 68.5d | EE; SupE | 16h |
| 4 | 1.1.2 | Mechanical layout |  | 10d? | 2006-01-02 | 2006-01-13 |  | 0d | ME | 80h |
| 5 | 1.1.3 | Generate prints |  | 10d? | 2006-01-16 | 2006-01-27 | 4 | 0d | MT | 80h |
| 6 | 1.1.4 | PDR | milestone | 0d | 2006-01-27 | 2006-01-27 | 5 | 0d |  |  |
| 7 | 1.2 | **Deployment frame** |  | 49.5d? | 2006-01-30 | 2006-04-07 |  | 0d |  | 528h |
| 8 | 1.2.1 | mechanical layout |  | 4d? | 2006-01-30 | 2006-02-02 | 6 | 0d | ME | 32h |
| 9 | 1.2.2 | Electrical layout |  | 1d? | 2006-02-03 | 2006-02-03 | 8 | 0d | EE | 8h |
| 10 | 1.2.3 | ROV interface |  | 2d? | 2006-02-06 | 2006-02-07 | 9 | 0d | ME | 16h |
| 11 | 1.2.4 | break-away hyd. |  | 2d? | 2006-02-08 | 2006-02-09 | 10 | 0d | ME | 16h |
| 12 | 1.2.5 | machine prints |  | 5d? | 2006-02-10 | 2006-02-16 | 11 | 0d | MT | 40h |
| 13 | 1.2.6 | CDR | milestone | 0d | 2006-02-16 | 2006-02-16 | 12 | 0d |  |  |
| 14 | 1.2.7 | **Construction** |  | 35.5d? | 2006-02-17 | 2006-04-07 | 13 | 0d |  | 416h |
| 15 | 1.2.7.1 | Parts purchasing |  | 1d? | 2006-02-17 | 2006-02-17 |  | 34.5d | ME | 8h |
| 16 | 1.2.7.2 | **Machine Parts** |  | 13d? | 2006-02-17 | 2006-03-07 |  | 0d |  | 120h |
| 17 | 1.2.7.2.1 | PV |  | 2d? | 2006-02-17 | 2006-02-20 |  | 33.5d | Machine shop | 16h |
| 18 | 1.2.7.2.2 | Optode adaptors |  | 3d? | 2006-02-17 | 2006-02-21 |  | 0d | Machine shop | 24h |
| 19 | 1.2.7.2.3 | motor parts (3) |  | 3d? | 2006-02-22 | 2006-02-24 | 18 | 0d | Machine shop | 24h |
| 20 | 1.2.7.2.4 | QD assy |  | 2d? | 2006-02-27 | 2006-02-28 | 19 | 0d | Machine shop | 16h |
| 21 | 1.2.7.2.5 | MRS frame/misc |  | 5d? | 2006-03-01 | 2006-03-07 | 20 | 0d | Machine shop | 40h |
| 22 | 1.2.7.3 | QC and assemble mechanicals |  | 3d? | 2006-03-08 | 2006-03-10 | 21 | 0d | MT | 24h |
| 23 | 1.2.7.4 | assemble and install sensors |  | 3d? | 2006-03-13 | 2006-03-15 | 22 | 0d | MT | 24h |
| 24 | 1.2.7.5 | wire up E-housing components |  | 1d? | 2006-03-16 | 2006-03-16 | 23 | 0d | MT; SupE | 16h |
| 25 | 1.2.7.6 | wire up processor/IO |  | 4d? | 2006-03-17 | 2006-03-22 | 24 | 0d | ET | 32h |
| 26 | 1.2.7.7 | Wire up U/W cables |  | 2d? | 2006-03-23 | 2006-03-24 | 25 | 0d | ET | 16h |
| 27 | 1.2.7.8 | wire up power/batteries |  | 1d? | 2006-03-27 | 2006-03-27 | 26 | 0d | ET | 8h |
| 28 | 1.2.7.9 | lab test |  | 1d? | 2006-03-28 | 2006-03-28 | 27, 34 | 0d | ME; SupE; EE | 24h |
| 29 | 1.2.7.10 | re-work |  | 1d? | 2006-03-29 | 2006-03-29 | 28 | 0d | ME; SupE; EE | 24h |
| 30 | 1.2.7.11 | re-test in lab |  | 1d? | 2006-03-30 | 2006-03-30 | 29 | 0d | EE; ME | 16h |

| ID | WBS | Task | Type | Duration | Start | Finish | Predecessors | Total slack | Free slack | Resources | Work |
| --- | --- | --- | --- | --- | --- | --- | --- | --- | --- | --- | --- |
| 31 | 1.2.7.12 | **Software** |  | 6d? | 2006-02-17 | 2006-02-24 |  | 21d |  |  | 48h |
| 32 | 1.2.7.12.1 | modify BRS code |  | 2d? | 2006-02-17 | 2006-02-20 |  | 21d | 0d | SE | 16h |
| 33 | 1.2.7.12.2 | test |  | 4d? | 2006-02-21 | 2006-02-24 | 32 | 21d | 0d | SE | 32h |
| 34 | 1.2.7.12.3 | Lab Test done | milestone | 0d | 2006-02-24 | 2006-02-24 | 33 | 21d |  |  |  |
| 35 | 1.2.7.13 | **Deployment** |  | 5.5d? | 2006-03-31 | 2006-04-07 |  | 0d |  |  | 56h |
| 36 | 1.2.7.13.1 | prep and mob |  | 1d? | 2006-03-31 | 2006-03-31 | 34, 30 | 0d |  | SE; SupE | 16h |
| 37 | 1.2.7.13.2 | depth capture, deck/lab incubation |  | 1d? | 2006-04-03 | 2006-04-03 | 36 | 0d |  | ME | 8h |
| 38 | 1.2.7.13.3 | re-work |  | 2d? | 2006-04-04 | 2006-04-05 | 37 | 0d |  | SE | 16h |
| 39 | 1.2.7.13.4 | prep and mob |  | 0.5d? | 2006-04-06 | 2006-04-06 | 38 | 0d |  | SE; ME | 8h |
| 40 | 1.2.7.13.5 | Midwater deployment |  | 1d? | 2006-04-06 | 2006-04-07 | 39 | 0d |  | SE | 8h |
